# SERVICIO DE TRANSFERENCIA INT., ADQUISICIÓN,EXPROPIACIÓN Y LIBERACION DE PREDIOS, ...RIO HUAURA

Schedule from Primavera P6, 2025-05-27 to 2026-02-20, data date 2025-05-27.

## Calendars

- J&M_DC: Mon-Sun 08:00-12:00, 13:00-17:00.
- J&M_DH: Mon-Fri 08:00-12:00, 13:00-17:00; Sat-Sun off. Exceptions (off unless hours are given): 2025-07-23, 2025-07-28 to 2025-07-29, 2025-08-06, 2025-10-08, 2025-12-08 to 2025-12-09, 2025-12-25, 2026-01-01.

## Schedule

| ID | WBS | Activity | Type | Duration | Start | Finish | Predecessors | Total float | Free float | Calendar | Resources | Entregables |
| --- | --- | --- | --- | --- | --- | --- | --- | --- | --- | --- | --- | --- |
|  | 01 | **HITOS DE PROYECTO** |  |  | 2025-05-27 | 2026-02-20 |  |  |  |  |  |  |
|  | 01 | **HITOS CONTRACTUALES** |  |  | 2025-05-27 | 2026-02-20 |  |  |  |  |  |  |
| HC_01 |  | Inicio Contractual | milestone | 0d | 2025-05-27 | 2025-05-27 |  | 0d |  |  |  |  |
| HC_04 |  | Fin Contractual | milestone | 0d | 2026-02-20 | 2026-02-20 | PC_EN06 | 0d |  |  |  |  |
|  | 02 | **HITOS POR ENTREGABLE** |  |  | 2025-06-25 | 2026-02-20 |  |  |  |  |  |  |
| PC_EN01 |  | Entregable 01: A los 30 días | milestone | 0d | 2025-06-25 | 2025-06-25 | CJJ-1080 | 130d | 20d |  |  |  |
| PC_EN02 |  | Entregable 02: A los 50 días | milestone | 0d | 2025-07-15 | 2025-07-15 | CJJ-1170, CJJ-1150, PC_EN01, CJJ-1130 | 110d | 50d |  |  |  |
| PC_EN03 |  | Entregable 03: A los 100 días | milestone | 0d | 2025-09-03 | 2025-09-03 | CJJ-1500, PC_EN02, CJJ-1230, CJJ-1310, CJJ-1400, CJJ-1450, CJJ-1350, CJJ-1580, CJJ-1180 FF | 60d |  |  |  |  |
| PC_EN04 |  | Entregable 04: A los 200 días | milestone | 0d | 2025-12-12 | 2025-12-12 | CJJ-1740, CJJ-1790 | 70d | 50d |  |  |  |
| PC_EN05 |  | Entregable 05: A los 250 días | milestone | 0d | 2026-01-31 | 2026-01-31 | CJJ-1750, CJJ-1770, PC_EN04, CJJ-1860, CJJ-1800 FF, CJJ-1810 FF | 20d |  |  |  |  |
| PC_EN06 |  | Entregable 06: A los 270 días | milestone | 0d | 2026-02-20 | 2026-02-20 | CJJ-1930, PC_EN05, CJJ-1890 | 0d |  |  |  |  |
|  | 02 | **ACTIVIDADES PRELIMINARES** |  |  | 2025-05-27 | 2025-05-29 |  |  |  |  |  |  |
| CJJAP-1000 |  | Ingreso y calificación del personal por parte de CJJ |  | 2d | 2025-05-27 | 2025-05-28 | HC_01 SS | 2d | 0d |  | CJJ [16 h] |  |
| CJJAP-1010 |  | Inducción del personal |  | 1d | 2025-05-29 | 2025-05-29 | CJJAP-1000 | 2d | 1d |  | CRN [8 h] |  |
|  | 03 | **DESARROLLO DE ACTIVIDADES - CUENCA HUAURA** |  |  | 2025-05-27 | 2026-02-20 |  |  |  |  |  |  |
|  | 01 | **FASE I: TRABAJOS DE CAMPO, ELABORACIÓN DELOS DTL Y LIBERACIÓN ANTICIPADA** |  |  | 2025-05-27 | 2025-07-15 |  |  |  |  |  |  |
|  | 01 | **TRABAJOS DE CAMPO (TOPOGRAFIA PREDIAL, RELEVANTAMIENTO SOCIAL) Y ELABORACIÓN DE DTL** |  |  | 2025-05-27 | 2025-06-25 |  |  |  |  |  |  |
|  | 01 | **REVISION, OBTENCION Y ANALISIS DE BASES GRAFICAS** |  |  | 2025-05-27 | 2025-06-14 |  |  |  |  |  |  |
| CJJ-1000 |  | Revisión de información proporcionada por OHLA |  | 2d | 2025-05-27 | 2025-05-28 | HC_01 SS | 12d | 0d |  | CJJ [16 h] | 01 |
| CJJ-1010 |  | Solicitud de información y reuniones con entidades/autoridades |  | 4d | 2025-05-27 | 2025-05-30 | HC_01 SS | 0d |  |  | CJJ [48 h] | 01 |
| CJJ-1020 |  | Recopilación y verificación de la georreferenciación de bases graficas |  | 15d | 2025-05-31 | 2025-06-14 | CJJ-1010, CJJ-1000 | 10d |  |  | CJJ [120 h] | 01 |
|  | 02 | **CERTIFICADOS DE BÚSQUEDA CATASTRAL (CBC)** |  |  | 2025-05-29 | 2025-06-23 |  |  |  |  |  |  |
| CJJ-1030 |  | Elaboración de los CBC |  | 4d | 2025-05-29 | 2025-06-01 | CJJ-1000 | 113d | 0d |  | CJJ [56 h] | 02 |
| CJJ-1040 |  | Presentación de los CBC a SUNARP |  | 1d | 2025-06-02 | 2025-06-02 | CJJ-1030 | 113d | 0d |  | CJJ [16 h] | 02 |
| CJJ-1050 |  | Respuesta de CBC (actividad realizada por terceros - SUNARP) |  | 15d | 2025-06-03 | 2025-06-23 | CJJ-1030, CJJ-1040 | 77d | 0d | J&M_DH | SUNARP [152 h] | 02 |

| ID | WBS | Activity | Duration | Start | Finish | Predecessors | Total float | Free float | Calendar | Resources | Entregables |
| --- | --- | --- | --- | --- | --- | --- | --- | --- | --- | --- | --- |
|  | 03 | **LEVANTAMIENTO TOPOGRÁFICO** |  | 2025-05-31 | 2025-06-25 |  |  |  |  |  |  |
| CJJ-1060 |  | Levantamiento topográfico de predios | 23d | 2025-05-31 | 2025-06-22 | CJJ-1010 | 131d | 1d |  | CJJ [200 h] | 01 |
| CJJ-1070 |  | Procesamiento de información y generación de mosaico | 24d | 2025-05-31 | 2025-06-23 | CJJ-1010 | 1d | 0d |  | CJJ [200 h] | 01 |
| CJJ-1080 |  | Informe de levantamiento topográfico | 2d | 2025-06-24 | 2025-06-25 | CJJ-1070, CJJ-1060 | 130d | 0d |  | CJJ [32 h] | 01 |
|  | 04 | **LEVANTAMIENTO DE INFORMACION DE SUJETO PASIVO** |  | 2025-05-31 | 2025-06-22 |  |  |  |  |  |  |
| CJJ-1090 |  | Identificación/entrevista con el afectado (Llenado de fichas) | 22d | 2025-05-31 | 2025-06-21 | CJJ-1010, CJJAP-1010 | 1d |  |  | CJJ [80 h] | 01 |
| CJJ-1100 |  | Recopilación de información legal del predio | 23d | 2025-05-31 | 2025-06-22 | CJJ-1010 | 0d |  |  | CJJ [184 h] |  |
|  | 02 | **DIAGNÓSTICO TÉCNICO LEGAL Y LIBERACIÓN ANTICIPADA** |  | 2025-06-23 | 2025-07-15 |  |  |  |  |  |  |
|  | 01 | **DIAGNÓSTICO TÉCNICO LEGAL** |  | 2025-06-23 | 2025-07-07 |  |  |  |  |  |  |
| CJJ-1110 |  | Análisis de documentación legal (partidas registrales, ficha reniec, declaración jurada de vecinos). | 2d | 2025-06-23 | 2025-06-24 | CJJ-1090, CJJ-1100 | 0d |  |  | CJJ [16 h] |  |
| CJJ-1130 |  | Análisis del CBC, elaboración del informe de verificador catastral | 5d | 2025-06-24 | 2025-06-28 | CJJ-1050 | 127d | 17d |  | CJJ [40 h] |  |
| CJJ-1120 |  | Diagnóstico de análisis técnico legal | 8d | 2025-06-25 | 2025-07-02 | CJJ-1110, CJJ-1070, CJJ-1020 | 0d |  |  | CJJ [56 h] |  |
| CJJ-1140 |  | Elaboración de padrón y plano clave de afectación | 2d | 2025-07-03 | 2025-07-04 | CJJ-1120 | 0d |  |  | CJJ [16 h] |  |
| CJJ-1150 |  | Informe general del Análisis técnico legal | 3d | 2025-07-05 | 2025-07-07 | CJJ-1140 | 0d |  |  | CJJ [16 h] |  |
|  | 02 | **LIBERACIÓN ANTICIPADA DEL BIEN INMUEBLE** |  | 2025-07-03 | 2025-07-15 |  |  |  |  |  |  |
| CJJ-1160 |  | Elaboración de Actas de Liberación Anticipada | 4d | 2025-07-03 | 2025-07-06 | CJJ-1120 | 60d | 0d |  | CJJ [80 h] | 04 |
| CJJ-1170 |  | Entrega de Actas de Liberación Anticipada o informes de Liberación Anticipada | 12d | 2025-07-04 | 2025-07-15 | CJJ-1160 SS+1d | 60d | 0d |  | CJJ [1240 h] | 04 |
|  | 2 | **FASE II: ELABORACIÓN DE EXPEDIENTES TECNICO - LEGALES (PRIVADOS Y PUBLICOS)** |  | 2025-07-08 | 2025-09-03 |  |  |  |  |  |  |
|  | 01 | **ELABORACIÓN DE EXPEDIENTE TECNICO LEGAL PREDIOS PRIVADOS** |  | 2025-07-08 | 2025-09-03 |  |  |  |  |  |  |
|  | 01 | **LIBERACIÓN ANTICIPADA DEL BIEN INMUEBLE - PARTE II** |  | 2025-07-16 | 2025-09-03 |  |  |  |  |  |  |
| CJJ-1180 |  | Entrega de Actas de Liberación Anticipada o informes de Liberación Anticipada | 50d | 2025-07-16 | 2025-09-03 | CJJ-1170 | 60d | 0d |  | CJJ [40 h] |  |
|  | 02 | **ANOTACIÓN PREVENTIVA ART. 5.5 (DE CORRESPONDER)** |  | 2025-07-08 | 2025-08-11 |  |  |  |  |  |  |
| CJJ-1190 |  | Elaboración de memoria descriptiva, planos y oficio dirigido a SUNARP | 7d | 2025-07-08 | 2025-07-14 | CJJ-1150 | 84d | 0d |  | CJJ [56 h] | 02 |
| CJJ-1200 |  | Revisión por parte de OHLA | 7d | 2025-07-15 | 2025-07-21 | CJJ-1190 | 84d | 0d |  | CRN [56 h] | 02 |
| CJJ-1210 |  | Revisiòn y firma de Anotaciones preventivas por ANIN | 7d | 2025-07-22 | 2025-07-28 | CJJ-1200 | 84d | 0d |  | ANIN [56 h] | 02 |
| CJJ-1220 |  | Presentación de la solicitud de anotación preventiva ante la SUNARP | 2d | 2025-07-29 | 2025-07-30 | CJJ-1210 | 84d | 0d |  | CJJ [16 h] | 02 |
| CJJ-1230 |  | Inscripción de Anotaciones preventivas por SUNARP (Dir. 09-2015-SUNARP) | 7d | 2025-07-31 | 2025-08-11 | CJJ-1220 | 58d | 17d | J&M_DH | SUNARP [72 h] | 02 |

| ID | WBS | Activity | Duration | Start | Finish | Predecessors | Total float | Free float | Calendar | Resources | Entregables |
| --- | --- | --- | --- | --- | --- | --- | --- | --- | --- | --- | --- |
|  | 03 | **GESTION PARA LA OBTENCION DE PUBLICACIONES** |  | 2025-07-08 | 2025-08-21 |  |  |  |  |  |  |
| CJJ-1240 |  | Elaboración de publicación, cotización y oficio | 5d | 2025-07-08 | 2025-07-12 | CJJ-1150 | 76d | 0d |  | CJJ [40 h] | 02 |
| CJJ-1250 |  | Revisión por parte de OHLA y envio a ANIN | 7d | 2025-07-13 | 2025-07-19 | CJJ-1240 | 76d | 0d |  | CRN [56 h] | 02 |
| CJJ-1260 |  | Revisiòn y firma de oficio por ANIN | 7d | 2025-07-20 | 2025-07-26 | CJJ-1250 | 76d | 0d |  | ANIN [56 h] | 02 |
| CJJ-1270 |  | Pago por las publicaciones | 2d | 2025-07-27 | 2025-07-28 | CJJ-1260 | 76d | 1d |  | CJJ [16 h] | 02 |
| CJJ-1280 |  | Las publicaciones (diario oficial El Peruano y diario de circulación nacional) | 5d | 2025-07-30 | 2025-08-05 | CJJ-1270 | 51d | 0d | J&M_DH | OTROS [40 h] | 02 |
| CJJ-1290 |  | Informe de no oposición a las publicaciones | 2d | 2025-08-06 | 2025-08-07 | CJJ-1280 | 73d | 0d |  | CJJ [16 h] | 02 |
| CJJ-1300 |  | Revisión del informe por parte de OHLA y envio a ANIN | 7d | 2025-08-08 | 2025-08-14 | CJJ-1290 | 73d | 0d |  | CRN [56 h] | 02 |
| CJJ-1310 |  | Revisión y emisión del memorandum de no oposición por parte de ANIN | 7d | 2025-08-15 | 2025-08-21 | CJJ-1300 | 73d | 13d |  | ANIN [56 h] | 02 |
|  | 04 | **AVISOS DE PUBICACIONES** |  | 2025-07-13 | 2025-08-03 |  |  |  |  |  |  |
| CJJ-1320 |  | Avisos de publicación, de conformidad con el del D.L. N°1192 y modificatorias (de corresponder) | 3d | 2025-07-13 | 2025-07-15 | CJJ-1240 | 91d | 0d |  | CJJ [24 h] | 03 |
| CJJ-1330 |  | Revisión de los avisos de publicación por parte de OHLA y envió a ANIN | 7d | 2025-07-16 | 2025-07-22 | CJJ-1320 | 91d | 0d |  | CRN [56 h] | 03 |
| CJJ-1340 |  | Revisión de los avisos de publicación por parte de ANIN | 7d | 2025-07-23 | 2025-07-29 | CJJ-1330 | 91d | 0d |  | ANIN [56 h] | 03 |
| CJJ-1350 |  | Notificación de las publicaciones al sujeto pasivo u ocupante | 5d | 2025-07-30 | 2025-08-03 | CJJ-1340 | 91d | 31d |  | CJJ [40 h] | 03 |
|  | 05 | **CARTA DE AFECTACIÓN** |  | 2025-07-08 | 2025-08-18 |  |  |  |  |  |  |
| CJJ-1360 |  | Elaboración de carta de afectación | 5d | 2025-07-08 | 2025-07-12 | CJJ-1150 | 77d | 0d |  | CJJ [88 h] | 02 |
| CJJ-1370 |  | Revisión por parte de OHLA y envió a ANIN | 7d | 2025-07-13 | 2025-07-19 | CJJ-1360 | 77d | 0d |  | CRN [24 h] | 02 |
| CJJ-1380 |  | Revisiòn y firma de carta de afectación por ANIN | 7d | 2025-07-20 | 2025-07-26 | CJJ-1370 | 77d | 0d |  | ANIN [56 h] | 02 |
| CJJ-1390 |  | Notificación de cartas de afectación al sujeto pasivo u ocupante | 8d | 2025-07-27 | 2025-08-03 | CJJ-1380 | 77d | 0d |  | CJJ [80 h] | 02 |
| CJJ-1400 |  | Respuesta por parte del sujeto pasivo u ocupante | 10d | 2025-08-04 | 2025-08-18 | CJJ-1390 | 53d | 12d | J&M_DH | SP [120 h] | 02 |
|  | 06 | **ANOTACIÓN PREVENTIVA ART. 16.2** |  | 2025-07-08 | 2025-08-15 |  |  |  |  |  |  |
| CJJ-1410 |  | Elaboración de oficio dirigido a SUNARP | 7d | 2025-07-08 | 2025-07-14 | CJJ-1150 | 84d | 0d |  | CJJ [56 h] | 02 |
| CJJ-1420 |  | Revisión por parte de OHLA | 7d | 2025-07-15 | 2025-07-21 | CJJ-1410 | 84d | 0d |  | CRN [56 h] | 02 |
| CJJ-1430 |  | Revisiòn y firma de Anotaciones preventivas por ANIN | 7d | 2025-07-22 | 2025-07-28 | CJJ-1420 | 84d | 6d |  | ANIN [56 h] | 02 |
| CJJ-1440 |  | Presentación de la solicitud de anotación preventiva ante la SUNARP | 2d | 2025-08-04 | 2025-08-05 | CJJ-1430, CJJ-1390 | 78d | 1d |  | CJJ [16 h] | 02 |
| CJJ-1450 |  | Inscripción de Anotaciones preventivas por SUNARP (Dir. 09-2015-SUNARP) | 7d | 2025-08-07 | 2025-08-15 | CJJ-1440 | 54d | 13d | J&M_DH | SUNARP [104 h] | 02 |

| ID | WBS | Activity | Duration | Start | Finish | Predecessors | Total float | Free float | Calendar | Resources | Entregables |
| --- | --- | --- | --- | --- | --- | --- | --- | --- | --- | --- | --- |
|  | 07 | **EXPEDIENTES DE TASACIÓN** |  | 2025-07-08 | 2025-09-03 |  |  |  |  |  |  |
| CJJ-1460 |  | Inventario de elementos a tasar del predio afectado | 16d | 2025-07-08 | 2025-07-23 | CJJ-1120, CJJ-1150 | 0d |  |  | CJJ [160 h] | 02 |
| CJJ-1470 |  | Elaboración de expedientes de tasación y oficio a MVCS | 15d | 2025-07-24 | 2025-08-07 | CJJ-1460 | 0d |  |  | CJJ [120 h] | 02 |
| CJJ-1480 |  | Revisión de los expedientes por parte de OHLA | 6d | 2025-08-08 | 2025-08-13 | CJJ-1470 | 0d |  |  | CRN [56 h] | 02 |
| CJJ-1490 |  | Revisión y firma por ANIN de expediente de tasación, y envío al MVCS | 7d | 2025-08-14 | 2025-08-20 | CJJ-1480 | 0d |  |  | ANIN [56 h] | 02 |
| CJJ-1500 |  | Calificación del expediente de tasación y emisión del monto del servicio MVCS | 10d | 2025-08-21 | 2025-09-03 | CJJ-1490 | 0d |  | J&M_DH | MVCS [104 h] | 02 |
|  | 02 | **ELABORACIÓN DE PLAN DE SANEAMIENTO FÍSICO Y LEGAL (TRANSFERENCIA INTERESTATAL) - PREDIOS PUBLICOS** |  | 2025-07-24 | 2025-09-02 |  |  |  |  |  |  |
|  | 01 | **EXPEDIENTES DE TRANSFERENCIA** |  | 2025-07-24 | 2025-09-02 |  |  |  |  |  |  |
| CJJ-1510 |  | Elaboración de expedientes de transferencia (PFSL, ET, MD y PLANOS) y oficio dirigido a SBN | 8d | 2025-07-24 | 2025-07-31 | CJJ-1460 | 76d | 0d |  | CJJ [128 h] | 02 |
| CJJ-1520 |  | Revisión de los expedientes de transferecnia por parte de OHLA | 3d | 2025-08-01 | 2025-08-03 | CJJ-1510 | 136d | 0d |  | CRN [56 h] | 02 |
| CJJ-1530 |  | Revisión y firma por ANIN de expediente de transferencia, y envío al SBN | 5d | 2025-08-04 | 2025-08-08 | CJJ-1520, CJJ-1050 | 136d | 2d |  | ANIN [56 h] | 02 |
| CJJ-1540 |  | Calificación de expedientes por parte de SBN (Art. 8.5 -ley 30556) | 7d | 2025-08-11 | 2025-08-19 | CJJ-1530 | 93d | 0d | J&M_DH | SBN [72 h] | 03 |
| CJJ-1550 |  | Presentación a SUNARP e Inscripción registral | 10d | 2025-08-20 | 2025-09-02 | CJJ-1540 | 93d | 80d | J&M_DH | SUNARP [88 h]; SBN [88 h] | 03 |
|  | 02 | **INFORME SIN SER LIMITATIVO (PREDIOS CON NECESIDAD DE SANEAMIENTO FÍSICO LEGAL)** |  | 2025-08-01 | 2025-08-18 |  |  |  |  |  |  |
| CJJ-1560 |  | Elaboración del informe técnico de verificador catastral | 10d | 2025-08-01 | 2025-08-10 | CJJ-1050, CJJ-1510 | 76d | 0d |  | CJJ [80 h] | 03 |
| CJJ-1570 |  | Revisión del informe por parte de OHLA | 5d | 2025-08-11 | 2025-08-15 | CJJ-1560 | 76d | 0d |  | CRN [80 h] | 03 |
| CJJ-1580 |  | Informe sin ser limitativo (predios con necesidad de saneamiento físico legal) | 3d | 2025-08-16 | 2025-08-18 | CJJ-1570 | 76d | 16d |  | CJJ [800 h] | 03 |
|  | 3 | **FASE III: ADQUISICIÓN Y/O EXPROPIACIÓNDE PREDIOS PRIVADOS Y TRANSFERENCIA INTERESTATAL** |  | 2025-09-04 | 2026-02-20 |  |  |  |  |  |  |
|  | 01 | **ADQUISICION DE PREDIOS POR TRATO DIRECTO** |  | 2025-09-04 | 2025-12-12 |  |  |  |  |  |  |
|  | 01 | **EXPEDIENTES DE TASACIÓN - PARTE II** |  | 2025-09-04 | 2025-10-07 |  |  |  |  |  |  |
| CJJ-1590 |  | Pago por servicio de tasación por parte del ANIN | 4d | 2025-09-04 | 2025-09-07 | CJJ-1500 | 0d |  |  | ANIN [16 h] |  |
| CJJ-1600 |  | Designación del perito, Tasación por el MVCS | 5d | 2025-09-08 | 2025-09-12 | CJJ-1590 | 0d |  | J&M_DH | MVCS [40 h] |  |
| CJJ-1610 |  | Emisión de ITT (Informe Técnico de Tasación - MVCS) de ANIN a CJJ | 15d | 2025-09-15 | 2025-10-03 | CJJ-1600 | 0d |  | J&M_DH | MVCS [120 h] |  |
| CJJ-1620 |  | Evaluación, conformidad a los ITT por parte de CJJ | 4d | 2025-10-04 | 2025-10-07 | CJJ-1610 | 0d |  |  | CJJ [16 h] |  |

| ID | WBS | Activity | Duration | Start | Finish | Predecessors | Total float | Free float | Calendar | Resources | Entregables |
| --- | --- | --- | --- | --- | --- | --- | --- | --- | --- | --- | --- |
|  | 02 | **CERTIFICACIÓN PRESUPUESTAL** |  | 2025-10-08 | 2025-10-15 |  |  |  |  |  |  |
| CJJ-1630 |  | Elaboración del memorandum | 1d | 2025-10-08 | 2025-10-08 | CJJ-1620 | 0d |  |  | CJJ [8 h] | 04 |
| CJJ-1640 |  | Revisión y envío de Memorandum de parte de OHLA a la ANIN | 3d | 2025-10-09 | 2025-10-11 | CJJ-1630 | 0d |  |  | CRN [32 h] | 04 |
| CJJ-1650 |  | Elaboración, aprobación y emisión de la certificación presupuestal del ANIN a OHLA | 4d | 2025-10-12 | 2025-10-15 | CJJ-1640 | 0d |  |  | ANIN [56 h] | 04 |
|  | 03 | **CARTA DE INTENCIÓN** |  | 2025-10-08 | 2025-10-30 |  |  |  |  |  |  |
| CJJ-1660 |  | Elaboración de las cartas de intención | 1d | 2025-10-08 | 2025-10-08 | CJJ-1620 | 0d |  |  | CJJ [8 h] | 04 |
| CJJ-1670 |  | Revisión de la carta de intención por parte de OHLA y envió a ANIN | 3d | 2025-10-09 | 2025-10-11 | CJJ-1660 | 0d |  |  | CRN [32 h] | 04 |
| CJJ-1680 |  | Devolución de carta de intención firmada por ANIN | 4d | 2025-10-12 | 2025-10-15 | CJJ-1670 | 0d |  |  | ANIN [56 h] | 04 |
| CJJ-1690 |  | Notificación de la carta de intención al sujeto pasivo | 5d | 2025-10-16 | 2025-10-20 | CJJ-1680, CJJ-1650 | 0d |  |  | CJJ [48 h] | 04 |
| CJJ-1700 |  | Respuesta de carta de intención por el sujeto pasivo (Aceptación, rechazo y/o falta de respuesta) | 5d | 2025-10-21 | 2025-10-27 | CJJ-1690 | 0d |  | J&M_DH | SP [56 h] | 04 |
| CJJ-1710 |  | Verificación en mesa de partes de ANIN de respuesta de sujeto Pasivo | 3d | 2025-10-28 | 2025-10-30 | CJJ-1700 | 7d |  |  | ANIN [56 h] | 04 |
|  | 04 | **INFORME TÉCNICO LEGAL (ITL)** |  | 2025-10-28 | 2025-11-06 |  |  |  |  |  |  |
| CJJ-1720 |  | Elaboración de proyecto de ITL | 1d | 2025-10-28 | 2025-10-28 | CJJ-1700 | 0d |  | J&M_DH | CJJ [40 h] | 04 |
| CJJ-1730 |  | Presentación de proyecto de ITL a OHLA | 3d | 2025-10-29 | 2025-10-31 | CJJ-1720 | 0d |  | J&M_DH | CRN [24 h] | 04 |
| CJJ-1740 |  | Aprobación del proyecto de ITL y emisión Resolución por ANIN (Incluye Cheque) | 4d | 2025-11-03 | 2025-11-06 | CJJ-1730, PC_EN03 | 0d |  | J&M_DH | ANIN [48 h] | 04 |
|  | 05 | **TRATO DIRECTO** |  | 2025-11-07 | 2025-12-12 |  |  |  |  |  |  |
| CJJ-1750 |  | Pago al sujeto pasivo y firma de formulario registral | 10d | 2025-11-07 | 2025-11-20 | CJJ-1740, CJJ-1710 | 0d |  | J&M_DH | CJJ [128 h] | 05 |
| CJJ-1760 |  | Entrega de inmueble por el sujeto pasivo | 10d | 2025-11-21 | 2025-12-04 | CJJ-1750 | 0d |  | J&M_DH | SP [96 h] | 05 |
| CJJ-1770 |  | Requerimiento para la entrega del inmueble | 1d | 2025-12-05 | 2025-12-05 | CJJ-1760 | 0d |  | J&M_DH | CJJ [16 h] | 05 |
| CJJ-1780 |  | Desocupación de inmueble por el sujeto pasivo | 6d | 2025-12-06 | 2025-12-11 | CJJ-1770 | 2d | 0d |  | ANIN [56 h] | 05 |
| CJJ-1790 |  | Gestiones de ejecución coactiva de trato directo | 1d | 2025-12-12 | 2025-12-12 | CJJ-1780 | 2d | 0d |  | CJJ [32 h] | 05 |
|  | 02 | **EXPROPIACIÓN** |  | 2025-12-13 | 2026-01-31 |  |  |  |  |  |  |
|  | 01 | **INFORME TÉCNICO LEGAL PARA APROBACIÓN DE LA EJECUCIÓN DE EXPROPIACIÓN** |  | 2025-12-13 | 2025-12-19 |  |  |  |  |  |  |
| CJJ-1800 |  | Elaboración del informe de expropiación | 7d | 2025-12-13 | 2025-12-19 | CJJ-1740, CJJ-1790 | 63d | 43d |  | CJJ [40 h] |  |
| CJJ-1810 |  | Elaboración de proyecto de resolución para aprobación de expropiación | 7d | 2025-12-13 | 2025-12-19 | CJJ-1740, CJJ-1790 | 63d | 43d |  | CJJ [40 h] |  |

| ID | WBS | Activity | Duration | Start | Finish | Predecessors | Total float | Free float | Calendar | Resources | Entregables |
| --- | --- | --- | --- | --- | --- | --- | --- | --- | --- | --- | --- |
|  | 02 | **NOTIFICACIÓN AL SUJETO PASIVO PARA LA ENTREGA DEL INMUEBLE** |  | 2025-12-15 | 2026-01-31 |  |  |  |  |  |  |
| CJJ-1820 |  | Consignación y notificación del oficio y resolución al sujeto pasivo | 10d | 2025-12-15 | 2025-12-29 | CJJ-1740, CJJ-1790 | 0d |  | J&M_DH | CJJ [112 h] | 05 |
| CJJ-1830 |  | Desocupación de inmueble por el sujeto pasivo | 10d | 2025-12-30 | 2026-01-13 | CJJ-1820 | 0d |  | J&M_DH | ANIN [112 h] | 05 |
| CJJ-1840 |  | Requerimiento para la entrega del inmueble | 6d | 2026-01-14 | 2026-01-19 | CJJ-1830 | 0d |  |  | CJJ [16 h] | 05 |
| CJJ-1850 |  | 2da Desocupación de inmueble por el sujeto pasivo | 7d | 2026-01-20 | 2026-01-26 | CJJ-1840 | 0d |  |  | ANIN [56 h] | 05 |
| CJJ-1860 |  | Gestiones de ejecución coactiva de expropiación | 5d | 2026-01-27 | 2026-01-31 | CJJ-1850 | 0d |  |  | CJJ [32 h] | 05 |
|  | 03 | **TRANSFERENCIA INTERESTATAL (PRIMERA DE DOMINIO)** |  | 2025-12-30 | 2026-01-28 |  |  |  |  |  |  |
| CJJ-1870 |  | Seguimiento del trámite y levantamiento de observaciones de SBN | 20d | 2025-12-30 | 2026-01-18 | CJJ-1790, CJJ-1550, CJJ-1820 | 29d | 13d |  | CJJ [160 h] |  |
| CJJ-1880 |  | Seguimiento del trámite ante SBN hasta su inscripción en SUNARP | 30d | 2025-12-30 | 2026-01-28 | CJJ-1550, CJJ-1790, CJJ-1820 | 19d | 3d |  | CJJ [160 h] |  |
|  | 03 | **CIERRE DE GESTIÓN** |  | 2026-02-01 | 2026-02-20 |  |  |  |  |  |  |
|  | 01 | **INFORME DE GESTIÓN DE LAS CONTINGENCIAS** |  | 2026-02-01 | 2026-02-04 |  |  |  |  |  |  |
| CJJ-1890 |  | Informe de gestión de las contingencias, detallado y sustentada | 4d | 2026-02-01 | 2026-02-04 | CJJ-1860, CJJ-1790, CJJ-1880, CJJ-1870 | 16d |  |  | CJJ [152 h] | 06 |
|  | 02 | **ELABORACIÓN DE INFORME FINAL DE CIERRE** |  | 2026-02-01 | 2026-02-20 |  |  |  |  |  |  |
| CJJ-1900 |  | Elaboración de Informe final de cierre y envió a OHLA | 7d | 2026-02-01 | 2026-02-07 | CJJ-1860 | 0d |  |  | CJJ [32 h] | 07 |
| CJJ-1910 |  | Revisión por parte de OHLA y envió a ANIN | 3d | 2026-02-08 | 2026-02-10 | CJJ-1900 | 0d |  |  | CRN [56 h] | 07 |
| CJJ-1920 |  | Revisión del Informe final por parte de ANIN | 7d | 2026-02-11 | 2026-02-17 | CJJ-1910 | 0d |  |  | ANIN [56 h] | 07 |
| CJJ-1930 |  | Entrega en físico (documentos originales) del total de los expedientes realizados | 3d | 2026-02-18 | 2026-02-20 | CJJ-1920 | 0d |  |  | CJJ [40 h] | 07 |
